# Spring 2008 Schedule~671

Schedule from MS Project, 2008-04-01 to 2008-06-06, A marks actual dates.

## Calendars

- Standard: Mon-Fri 08:00-12:00, 13:00-17:00; Sat-Sun off. Exceptions (off unless hours are given): 2008-04-06 08:00-12:00, 13:00-17:00, 2008-04-12 to 2008-04-13 08:00-12:00, 13:00-17:00, 2008-04-19 08:00-12:00, 13:00-17:00.

## Schedule

| ID | Task | Duration | Start | Finish | Predecessors | Complete | Remaining | Total slack | Free slack | Constraint |
| --- | --- | --- | --- | --- | --- | --- | --- | --- | --- | --- |
| 1 | Build all unary gates in lab | 0.8w? | 2008-04-01 A | 2008-04-04 A |  | 100% |  |  |  | finish no earlier than 2008-04-04 |
| 2 | Build a 3:1 multiplexer | 2.5d? | 2008-04-03 A | 2008-04-07 A | 1 | 100% |  |  |  |  |
| 3 | Antonio learn Ltspice | 3d? | 2008-04-02 A | 2008-04-04 A |  | 100% |  |  |  | start no earlier than 2008-04-02 |
| 4 | Chirag learn and setup git | 10d? | 2008-04-02 A | 2008-04-13 A |  | 100% |  |  |  | finish no earlier than 2008-04-13 |
| 5 | Himanshu setup git | 11d? | 2008-04-11 A | 2008-04-22 |  | 18% | 9d? | 33d |  | start no earlier than 2008-04-11 |
| 6 | Himanshu run LTspice Ohm's Law tutorial | 7d? | 2008-04-14 | 2008-04-21 |  |  |  | 34d |  | finish no earlier than 2008-04-21 |
| 7 | Himanshu find critical voltages & noise margins of tinv | 17d | 2008-04-09 | 2008-04-28 |  |  |  | 28d | 0d | start no earlier than 2008-04-09 |
| 8 | Himanshu administrative tasks | 13d? | 2008-04-01 A | 2008-04-14 A |  | 100% |  |  |  | finish no earlier than 2008-04-14 |
| 9 | ? Himanshu crit. voltages of FD and RD | 1d? | 2008-04-29 | 2008-04-29 | 7 |  |  | 28d |  | finish no earlier than 2008-04-29 |
| 10 | ? Himanshu criti. voltages & NM of dyadic gates | 1d? | 2008-04-29 | 2008-04-29 |  |  |  | 28d |  | finish no earlier than 2008-04-29 |
| 11 | Expression evaluator working | 1.4w? | 2008-04-01 A | 2008-04-09 A |  | 100% |  |  |  | finish no earlier than 2008-04-09 |
| 12 | Order and receive purchase #3 | 14d? | 2008-04-02 A | 2008-04-16 |  | 71% | 4d? | 38d |  | finish no earlier than 2008-04-16 |
| 13 | Senior project proposal due | 1d? | 2008-04-07 A | 2008-04-07 A |  | 100% |  |  |  | start no earlier than 2008-04-07 |
| 14 | Build dyadic gates in lab | 0.5w? | 2008-04-08 A | 2008-04-10 A |  | 100% |  |  |  | start no earlier than 2008-04-09 |
| 15 | Build ternary cycling gate | 3d? | 2008-04-16 A | 2008-04-18 A |  | 100% |  |  |  | finish no earlier than 2008-04-18 |
| 16 | Wiki server RAID 0+1->1 disk upgrades | 7d? | 2008-04-06 A | 2008-04-12 A |  | 100% |  |  |  | start no earlier than 2008-04-06 |
| 17 | Honors Open House - decide on timeslot | 11d? | 2008-04-09 A | 2008-04-19 |  | 55% | 5d? | 35d |  | finish no earlier than 2008-04-19 |
| 18 | Honors Open House Poster Due | 9d? | 2008-04-08 | 2008-04-16 |  |  |  | 37d |  | finish no earlier than 2008-04-16 |
| 19 | Instruction-level simulator working | 5.5d? | 2008-04-10 A | 2008-04-15 | 11 | 55% | 2.5d? | 39.5d |  |  |
| 20 | Honors Open House Presentation 1:30-2 | 1d? | 2008-04-19 | 2008-04-19 |  |  |  | 35d |  | finish no earlier than 2008-04-19 |
| 21 | Simulate all tri-flop circuits | 16d? | 2008-04-03 A | 2008-04-21 |  | 31% | 11d? | 34d |  | finish no earlier than 2008-04-21 |
| 22 | Design PCB for 9-bit SWROM | 5d? | 2008-04-21 | 2008-04-25 |  |  |  | 15d |  | finish no earlier than 2008-04-25 |
| 23 | Fabricate PCB for 9-bit SWROM | 10d? | 2008-04-28 | 2008-05-09 | 22 |  |  | 15d | 0d | start no earlier than 2008-04-28 |
| 24 | Test 9-bit SWROM with cycling gate | 5d? | 2008-05-12 | 2008-05-16 | 23 |  |  | 15d |  | start no earlier than 2008-05-12 |
| 25 | Build dtflop-ms tri-flop circuit | 9.5d? | 2008-04-10 A | 2008-04-19 |  | 47% | 5d? | 35d |  | finish no earlier than 2008-04-19 |
| 26 | Enhance expr. eval. & other tools; generate circuits, GUI | 12d? | 2008-04-18 | 2008-05-02 | 11 |  |  | 25d |  | start no earlier than 2008-04-18 |
| 27 | Circuit layout program | 8d? | 2008-04-11 A | 2008-04-18 |  | 50% | 4d? | 36d |  | finish no earlier than 2008-04-18 |
| 28 | Design and build ALU | 6d? | 2008-04-30 | 2008-05-07 |  |  |  | 12.5d | 0d | start no earlier than 2008-04-30 |
| 29 | Decide about reading textbook | 7d? | 2008-05-01 | 2008-05-10 |  |  |  | 20d |  | finish no earlier than 2008-05-10 |
| 30 | Design and build instruction decoder | 8d? | 2008-05-05 | 2008-05-14 |  |  |  | 7d |  | start no earlier than 2008-05-05 |
| 31 | High-level language to asm compiler | 22d? | 2008-04-22 | 2008-05-21 |  |  |  | 12d |  | start no earlier than 2008-04-22 |
| 32 | Integration | 7.5d? | 2008-05-08 | 2008-05-19 | 28 |  |  | 12.5d |  |  |
| 33 | Finishing touches or catch up | 14d? | 2008-05-16 | 2008-06-04 |  |  |  | 2d |  | start no earlier than 2008-05-16 |
| 34 | Expression creator functional | 6d | 2008-04-16 | 2008-04-22 |  |  |  | 29d | 0d | start no earlier than 2008-04-16 |
| 35 | Base 3 converter functional | 4d | 2008-04-23 | 2008-04-28 | 34 |  |  | 29d |  |  |
| 36 | Honors Progress Report Due | 2d | 2008-05-06 | 2008-05-07 |  |  |  | 22d |  | finish no earlier than 2008-05-07 |
| 37 | Honors Progress Report Due | 1d? | 2008-05-29 | 2008-05-29 |  |  |  | 6d |  | finish no earlier than 2008-05-29 |
| 38 | Honors Final Report Due (9 pm) | 5d? | 2008-06-02 | 2008-06-06 |  |  |  | 0d |  | finish no earlier than 2008-06-06 |
| 39 | Senior project spec & schedule draft due | 6d? | 2008-05-16 | 2008-05-23 |  |  |  | 10d |  | finish no earlier than 2008-05-23 |
| 40 | Senior project spec & schedule final due | 6d? | 2008-05-30 | 2008-06-06 |  |  |  | 0d |  | finish no earlier than 2008-06-06 |

Notes:
- 12: 2008-04-03 Jeff requested quote #3 from Digi-Key / 2008-04-08 Chirag gave quote #3 to Cindy to order / 2008-04-14 Contacted Debbie Tuson, extension 6-6116 on campus, said she would give the order to the purchasing girl this morning
